# CAParseAcc

Schedule from MS Project, 2006-08-01 to 2009-07-31.
Middlesex University

## Calendars

- Standard: Mon-Fri 08:00-12:00, 13:00-17:00; Sat-Sun off.

## Resources

| Resource | Rate | Cost per use |
| --- | --- | --- |
| Chris | 5920000 | 400 |
| Roman |  |  |
| Colm |  |  |
| PhD |  |  |

## Schedule

| ID | WBS | Task | Type | Duration | Start | Finish | Baseline start | Baseline finish | Baseline duration | Total slack | Constraint | Resources | Work |
| --- | --- | --- | --- | --- | --- | --- | --- | --- | --- | --- | --- | --- | --- |
| 1 | 1 | **Project** |  | 784d | 2006-08-01 | 2009-07-31 | 2005-07-20 | 2009-02-27 | 943d? | 0d |  |  | 26424h |
| 2 | 1.1 | Phase 1: Parser |  | 261d | 2006-08-01 | 2007-07-31 | 2006-03-01 | 2007-02-28 | 261d | 523d | start no earlier than 2006-08-01 |  |  |
| 3 | 1.2 | Rule Application |  | 12.33d | 2006-08-01 | 2006-08-17 | 2006-03-01 | 2006-03-17 | 12.33d | 771.67d | start no earlier than 2006-08-01 | Chris; Roman; Colm | 296h |
| 4 | 1.3 | Stack |  | 43d | 2006-09-04 | 2006-11-01 | 2006-04-03 | 2006-05-31 | 43d | 717d | start no earlier than 2006-09-04 | Colm; Chris | 688h |
| 5 | 1.4 | Word Representation |  | 43d | 2006-11-01 | 2006-12-29 | 2006-06-01 | 2006-07-31 | 43d? | 675d | start no earlier than 2006-11-01 | Chris; Colm | 688h |
| 6 | 1.5 | Grammar Rule Applied | milestone | 0d | 2006-12-04 | 2006-12-04 | 2006-07-03 | 2006-07-03 | 0d | 695d | start no earlier than 2006-12-04 | Colm |  |
| 7 | 1.6 | Simple Grammar Development |  | 43d | 2006-12-04 | 2007-01-31 | 2005-07-20 | 2005-07-20 | 1d? | 652d | start no earlier than 2006-12-04 | Chris; Colm | 688h |
| 8 | 1.7 | Develop Frame System |  | 33d | 2007-02-01 | 2007-03-19 | 2005-07-20 | 2005-07-20 | 1d? | 619d | start no earlier than 2007-02-01 | Colm; Chris | 528h |
| 9 | 1.8 | Develop Test Corpus |  | 50d | 2006-12-04 | 2008-06-02 | 2005-07-20 | 2005-07-20 | 1d? | 304.75d | start no earlier than 2006-12-04 | Chris | 400h |
| 10 | 1.9 | Develop Semantic Output |  | 34d | 2007-03-19 | 2007-05-03 | 2005-07-20 | 2005-07-20 | 1d? | 586d | start no earlier than 2007-03-19 | Colm; Chris | 544h |
| 11 | 1.10 | Parsing Test | milestone | 0d | 2007-05-01 | 2007-05-01 | 2006-12-01 | 2006-12-01 | 0d | 589d | start no earlier than 2007-05-01 | Colm; Chris |  |
| 12 | 1.11 | Phase 2: Sensing |  | 262d | 2007-08-01 | 2008-07-31 | 2007-03-01 | 2008-02-29 | 262d? | 261d | start no earlier than 2007-08-01 |  |  |
| 13 | 1.12 | HalfLife Integration |  | 30d | 2007-07-02 | 2007-08-10 |  |  |  | 515d | start no earlier than 2007-07-02 | Chris; Colm; PhD | 720h |
| 14 | 1.13 | Line Detection |  | 65d | 2006-10-02 | 2006-12-29 | 2005-07-20 | 2005-07-20 | 1d? | 675d | start no earlier than 2006-10-02 | PhD; Chris | 1040h |
| 15 | 1.14 | Line Combination |  | 66d | 2007-01-01 | 2007-04-02 | 2005-07-20 | 2005-07-20 | 1d? | 609d | start no earlier than 2007-01-01 | PhD; Chris | 1056h |
| 16 | 1.15 | Simple Object Recognition |  | 129d | 2007-04-02 | 2008-02-28 |  |  |  | 371d | start no earlier than 2007-04-02 | PhD; Chris | 2064h |
| 17 | 1.16 | Object Recognition Test | milestone | 0d | 2007-08-15 | 2007-08-15 |  |  |  | 513d | start no earlier than 2007-08-15 | Chris; PhD |  |
| 18 | 1.17 | Figure Ground Separation |  | 122d | 2007-09-03 | 2008-04-25 |  |  |  | 330d | start no earlier than 2007-09-03 | Chris; PhD | 1952h |
| 19 | 1.18 | Object Naming |  | 66d | 2007-10-01 | 2007-12-31 |  |  |  | 414d | start no earlier than 2007-10-01 | Colm; Chris; PhD | 1584h |
| 20 | 1.19 | Object Naming Test | milestone | 0d | 2008-01-01 | 2008-01-01 |  |  |  | 414d | start no earlier than 2008-01-01 | Colm; Chris |  |
| 21 | 1.20 | Integrate with Parser |  | 121d | 2007-08-16 | 2008-01-31 |  |  |  | 391d | start no earlier than 2007-08-16 | Colm; Chris | 1936h |
| 22 | 1.21 | Repeat Parsing Test | milestone | 0d | 2008-06-23 | 2008-06-23 |  |  |  | 290d | start no earlier than 2008-06-23 | Colm |  |
| 23 | 1.22 | Phase 3: Motion |  | 260d | 2008-08-04 | 2009-07-31 | 2008-03-03 | 2009-02-27 | 260d? | 0d | start no earlier than 2008-08-04 |  |  |
| 24 | 1.23 | Develop Spreading Act. Net |  | 66d | 2008-08-04 | 2008-11-03 |  |  |  | 194d | start no earlier than 2008-08-04 | Colm | 528h |
| 25 | 1.24 | Sensing with Motion |  | 165d | 2008-05-05 | 2009-03-18 |  |  |  | 97d | start no earlier than 2008-05-05 | PhD; Chris | 2640h |
| 26 | 1.25 | Integrate Goals, and Motion Sensing |  | 63d | 2008-11-04 | 2009-01-29 |  |  |  | 131d | start no earlier than 2008-11-04 | Colm; Chris; PhD | 1512h |
| 27 | 1.26 | Test Working Agent | milestone | 0d | 2009-02-02 | 2009-02-02 |  |  |  | 130d | start no earlier than 2009-02-02 | Colm; Chris |  |
| 28 | 1.27 | Mapping, Goals, Planning, etc. |  | 130d | 2009-02-02 | 2009-07-31 |  |  |  | 0d | start no earlier than 2009-02-02 | Colm; Chris; Roman; PhD | 4160h |
| 29 | 1.28 | Final Agent Test | milestone | 0d | 2009-06-15 | 2009-06-15 |  |  |  | 35d | start no earlier than 2009-06-15 | Chris; Colm |  |
| 30 | 1.29 | Rule generation |  | 65d | 2006-11-01 | 2008-09-24 | 2005-07-20 | 2005-07-20 | 1d? | 222d | start no earlier than 2006-11-01 | Roman | 520h |
| 31 | 1.30 | Develop State Formation Theory |  | 90d | 2006-09-04 | 2008-10-24 |  |  |  | 200d | start no earlier than 2006-09-04 | Chris; Colm; PhD; Roman | 2880h |
